# Home Construction

How a schedule from Primavera P6 changed from version to version. A marks actual dates.

## Version 1 (data date 2014-10-17, saved 2015-03-30, file c04_CONS_Home_tut02.xer)

| ID | WBS | Task | Duration | Start | Finish | Predecessors | Total float |
| --- | --- | --- | --- | --- | --- | --- | --- |
| A1000 |  | Project Start | 0d | 2014-10-17 | 2014-10-17 |  |  |
| A1010 |  | Project Management | 32d | 2014-10-17 | 2014-11-19 | A1000 SS | 1d |
| A1020 |  | Project Complete | 0d | 2014-11-19 | 2014-11-19 | A1010 FF, A1150, A1170 FF, A1240 FF, A1210 FF | 1d |
|  | 1 | **Grading** |  | 2014-10-15 | 2014-10-22 |  |  |
| A1040 |  | Grade Site | 5d | 2014-10-15 | 2014-10-22 | A1030 |  |
| A1030 |  | Survey and mark out Site | 2d | 2014-10-17 | 2014-10-17 | A1000 SS |  |
|  | 2 | **Foundation** |  | 2014-10-18 | 2014-10-24 |  |  |
| A1050 |  | Laying of Foundation | 2d | 2014-10-18 | 2014-10-22 | A1040 |  |
| A1060 |  | Slab Plumbing | 1d | 2014-10-22 | 2014-10-23 | A1050 | 0d |
| A1070 |  | Pour and float slab concrete | 1d | 2014-10-23 | 2014-10-24 | A1060 | 0d |
|  | 3 | **Structure** |  | 2014-10-17 | 2014-11-20 |  |  |
|  | 1 | **Framing** |  | 2014-11-01 | 2014-11-14 |  |  |
| A1080 |  | Exterior Walls | 6d | 2014-11-01 | 2014-11-08 | A1070 FS+7d | 0d |
| A1090 |  | Interior Walls | 4d | 2014-11-08 | 2014-11-14 | A1080 | 5d |
| A1100 |  | Exterior Cladding | 2d | 2014-11-08 | 2014-11-12 | A1080 | 1d |
|  | 2 | **Roof** |  | 2014-11-08 | 2014-11-15 |  |  |
| A1110 |  | Truss Placing | 2d | 2014-11-08 | 2014-11-12 | A1080 | 2d |
| A1120 |  | Roof Sheeting | 1d | 2014-11-12 | 2014-11-13 | A1110 | 2d |
| A1130 |  | Place Paper and Shingles | 2d | 2014-11-13 | 2014-11-15 | A1120 | 2d |
|  | 3 | **Interior** |  | 2014-10-17 | 2014-11-20 |  |  |
|  | 1 | **Mechanical** |  | 2014-11-15 | 2014-11-19 |  |  |
| A1140 |  | HVAC Ducting | 2d | 2014-11-15 | 2014-11-19 | A1130 | 2d |
| A1150 |  | Install HVAC Unit | 1d | 2014-11-15 | 2014-11-18 | A1140 SS | 3d |
|  | 2 | **Electrical** |  | 2014-11-08 | 2014-11-18 |  |  |
| A1160 |  | Breaker Box and Rough Wiring | 3d | 2014-11-08 | 2014-11-13 | A1080 | 3d |
| A1170 |  | Finish Wiring | 3d | 2014-11-13 | 2014-11-18 | A1160 | 3d |
|  | 3 | **Plumbing** |  | 2014-11-08 | 2014-11-14 |  |  |
| A1180 |  | Install Rough Plumbing Lines | 4d | 2014-11-08 | 2014-11-14 | A1080 | 0d |
|  | 4 | **Decor** |  | 2014-10-17 | 2014-11-20 |  |  |
| A1210 |  | Kitchen Cabinets | 5d | 2014-10-17 | 2014-10-23 |  | 23d |
| A1190 |  | Placing Doors | 2d | 2014-11-14 | 2014-11-18 | A1180 | 0d |
| A1200 |  | Doors Casing and Baseboards | 3d | 2014-11-18 | 2014-11-20 | A1190 | 0d |
|  | 4 | **Exterior** |  | 2014-11-12 | 2014-11-19 |  |  |
| A1220 |  | Place Windows | 2d | 2014-11-12 | 2014-11-14 | A1100 | 1d |
| A1230 |  | Window Sidings | 3d | 2014-11-14 | 2014-11-19 | A1220 | 1d |
|  | 5 | **Landscaping** |  | 2014-11-19 | 2014-11-19 |  |  |
| A1240 |  | Tree Plantings | 1d | 2014-11-19 | 2014-11-19 | A1230 | 1d |

## Version 2 (data date 2015-10-13, saved 2015-12-19, file c06_CONS_HOME_tut02.xer)

Last finish 2014-11-20 → 2016-01-08 (+414d).

Added:

| ID | Task | Duration | Start | Finish | Predecessors | Resources |
| --- | --- | --- | --- | --- | --- | --- |
| A1040 | Site Demarcation | 1d | 2015-10-15 | 2015-10-16 | A1030 | Land Surveyor [64 h] |
| A1050 | Excavation | 3.12d | 2015-10-17 | 2015-10-22 | A1040 FS+1d | Truck Crane [32 ea] |
| A1090 | Pour and Float slab concrete | 2d | 2015-10-24 | 2015-10-28 | A1080 | Concrete [16 cu yd] |
| A1240 | Place Window | 12d | 2015-10-13 | 2015-10-27 |  | Glass Crew [768 h]; Carpentry Crew [768 h] |

Removed: A1070 Pour and float slab concrete; A1160 Breaker Box and Rough Wiring

Changed:

| ID | Task | Start | Finish | Duration | Total float | Predecessors | Other |
| --- | --- | --- | --- | --- | --- | --- | --- |
| A1000 | Project Start | 2014-10-17 → 2015-10-13 (+361d) | 2014-10-17 → 2015-10-13 (+361d) |  | none → 61d |  |  |
| A1010 | Project Management | 2014-10-17 → 2015-10-13 (+361d) | 2014-11-19 → 2016-01-07 (+414d) | 32d → 72d |  |  | resources none → Daniel Muller [4608 h] |
| A1020 | Project Complete | 2014-11-19 → 2016-01-07 (+414d) | 2014-11-19 → 2016-01-07 (+414d) |  |  | A1010 FF, A1170, A1190 FF, A1260 FF, A1230 FF → A1010 FF, A1170 FF, A1190, A1230 FF, A1260 FF |  |
| 1 | **Grading** | 2014-10-15 → 2015-10-13 (+363d) | 2014-10-22 → 2015-10-23 (+366d) |  |  |  |  |
| A1030 | Survey and mark out site | 2014-10-17 → 2015-10-13 (+361d) | 2014-10-17 → 2015-10-15 (+363d) | 2d → 3d | none → 61d |  | was named Survey and mark out Site; resources none → Land Surveyor [192 h] |
| A1060 | Grade Site | 2014-10-15 → 2015-10-22 (+372d) | 2014-10-22 → 2015-10-23 (+366d) | 5d → 2d | none → 61d | A1030 → A1050 | resources none → Operating Engineer [128 h] |
| 2 | **Foundation** | 2014-10-18 → 2015-10-13 (+360d) | 2014-10-24 → 2015-10-28 (+369d) |  |  |  |  |
| A1070 | Laying of Foundation | 2014-10-18 → 2015-10-13 (+360d) | 2014-10-22 → 2015-10-16 (+359d) | 2d → 4d | none → 0d | A1060 → none | resources none → Engineer Labor [256 h]; Steel Crew [256 h]; Carpentry Crew [256 h]; Mason [256 h] |
| A1080 | Slab Plumbing | 2014-10-22 → 2015-10-16 (+359d) | 2014-10-23 → 2015-10-24 (+366d) | 1d → 7d |  |  | resources none → Plumbing Crew [448 h] |
| 3 | **Structure** | 2014-10-17 → 2015-10-13 (+361d) | 2014-11-20 → 2016-01-08 (+414d) |  |  |  |  |
| 1 | **Framing** | 2014-11-01 → 2015-11-05 (+369d) | 2014-11-14 → 2016-01-07 (+419d) |  |  |  |  |
| A1100 | Exterior Walls | 2014-11-01 → 2015-11-05 (+369d) | 2014-11-08 → 2015-12-01 (+388d) | 6d → 20d |  | Pour and float slab concrete FS+7d → A1090 FS+7d | resources none → Mason [1280 h]; Plaster Crew [1280 h] |
| A1120 | Exterior Cladding | 2014-11-08 → 2015-12-01 (+388d) | 2014-11-12 → 2016-01-07 (+421d) | 2d → 30d |  |  | resources none → Mason [1920 h] |
| A1110 | Interior Walls | 2014-11-08 → 2015-12-04 (+391d) | 2014-11-14 → 2016-01-05 (+417d) | 4d → 25d | 5d → 3d | A1100 → A1100 FS+3d | resources none → Plaster Crew [1600 h]; Mason [1600 h] |
| 2 | **Roof** | 2014-11-08 → 2015-12-01 (+388d) | 2014-11-15 → 2016-01-05 (+416d) |  |  |  |  |
| A1130 | Truss Placing | 2014-11-08 → 2015-12-01 (+388d) | 2014-11-12 → 2015-12-18 (+401d) | 2d → 15d | 2d → 0d |  | resources none → Steel Crew [960 h] |
| A1140 | Roof Sheeting | 2014-11-12 → 2015-12-18 (+401d) | 2014-11-13 → 2015-12-31 (+413d) |  | 2d → 0d |  | resources none → Skilled Laborer [64 h] |
| A1150 | Place Paper and Shingles | 2014-11-13 → 2015-12-31 (+413d) | 2014-11-15 → 2016-01-05 (+416d) | 2d → 3d | 2d → 0d |  | resources none → Skilled Laborer [192 h] |
| 3 | **Interior** | 2014-10-17 → 2015-10-13 (+361d) | 2014-11-20 → 2016-01-08 (+414d) |  |  |  |  |
| 1 | **Mechanical** | 2014-11-15 → 2016-01-05 (+416d) | 2014-11-19 → 2016-01-08 (+415d) |  |  |  |  |
| A1160 | HVAC Ducting | 2014-11-15 → 2016-01-05 (+416d) | 2014-11-19 → 2016-01-08 (+415d) | 2d → 3d | 2d → 0d |  | resources none → Richard Collins [192 h] |
| A1170 | Install HVAC Unit | 2014-11-15 → 2016-01-05 (+416d) | 2014-11-18 → 2016-01-07 (+415d) | 1d → 2d | 3d → 1d |  | resources none → Richard Collins [128 h] |
| 2 | **Electrical** | 2014-11-08 → 2015-12-01 (+388d) | 2014-11-18 → 2015-12-16 (+393d) |  |  |  |  |
| A1180 | Breaker Box and Rough Wire | 2014-11-08 → 2015-12-01 (+388d) | 2014-11-14 → 2015-12-05 (+386d) | 4d → 5d | 0d → 19d |  | was named Install Rough Plumbing Lines; resources none → Electrical Crew [320 h] |
| A1190 | Finish Wiring | 2014-11-13 → 2015-12-08 (+390d) | 2014-11-18 → 2015-12-16 (+393d) | 3d → 7d | 3d → 19d | Breaker Box and Rough Wiring → A1180 | resources none → Electrical Crew [448 h] |
| 3 | **Plumbing** | 2014-11-08 → 2015-12-01 (+388d) | 2014-11-14 → 2015-12-12 (+393d) |  |  |  |  |
| A1200 | Install Rough Plumbing lines | 2014-11-18 → 2015-12-01 (+378d) | 2014-11-20 → 2015-12-12 (+387d) | 3d → 10d | 0d → 7d | A1210 → A1100 | was named Doors Casing and Baseboards; resources none → Plumbing Crew [640 h] |
| 4 | **Decor** | 2014-10-17 → 2015-10-13 (+361d) | 2014-11-20 → 2015-12-30 (+405d) |  |  |  |  |
| A1230 | Kitchen Cabinets | 2014-10-17 → 2015-10-13 (+361d) | 2014-10-23 → 2015-10-23 (+365d) | 5d → 10d | 23d → 61d |  | resources none → Carpentry Crew [640 h] |
| A1210 | Placing Doors | 2014-11-14 → 2015-12-12 (+393d) | 2014-11-18 → 2015-12-23 (+400d) | 2d → 8d | 0d → 7d | A1180 → A1200 | resources none → Carpentry Crew [512 h] |
| A1220 | Door Casings and Baseboards | 2014-11-12 → 2015-12-23 (+406d) | 2014-11-14 → 2015-12-30 (+411d) | 2d → 6d | 1d → 7d | A1120 → A1210 | was named Place Windows; resources none → Carpentry Crew [384 h] |
| 4 | **Exterior** | 2014-11-12 → 2015-10-13 (+335d) | 2014-11-19 → 2015-11-03 (+349d) |  |  |  |  |
| A1250 | Window Sidings | 2014-11-14 → 2015-10-27 (+347d) | 2014-11-19 → 2015-11-03 (+349d) | 3d → 5d | 1d → 49d | A1220 → A1240 | resources none → Siding Contractor [320 h] |
| 5 | **Landscaping** | 2014-11-19 → 2015-11-03 (+349d) | 2014-11-19 → 2015-11-07 (+353d) |  |  |  |  |
| A1260 | Tree Plantings | 2014-11-19 → 2015-11-03 (+349d) | 2014-11-19 → 2015-11-07 (+353d) | 1d → 5d | 1d → 49d |  | resources none → Landscape Crew [320 h] |

## Version 3 (data date 2018-09-29, saved 2018-11-01, file c04_CONS_Home_Activities_tut01.xer)

Last finish 2016-01-08 → 2018-11-06 (+1033d).

Added:

| ID | Task | Start | Finish |
| --- | --- | --- | --- |
| 1 | **Mechnical** | 2018-09-29 | 2018-10-03 |

Removed: Mechanical

Changed:

| ID | Task | Start | Finish | Duration | Total float | Predecessors | Other |
| --- | --- | --- | --- | --- | --- | --- | --- |
| A1000 | Project Start | 2015-10-13 → 2018-09-29 (+1082d) | 2015-10-13 → 2018-09-29 (+1082d) |  | 61d → none |  |  |
| A1010 | Project Management | 2015-10-13 → 2018-09-29 (+1082d) | 2016-01-07 → 2018-10-05 (+1002d) | 72d → 5d | 1d → none |  | resources Daniel Muller [4608 h] → Daniel Muller [680 h] |
| A1020 | Project Complete | 2016-01-07 → 2018-09-29 (+996d) | 2016-01-07 → 2018-09-29 (+996d) |  | 1d → none | A1010 FF, A1170 FF, A1190, A1230 FF, A1260 FF → A1010 FF, A1170, A1190, A1230, A1260 |  |
| 1 | **Grading** | 2015-10-13 → 2018-09-29 (+1082d) | 2015-10-23 → 2018-10-03 (+1076d) |  |  |  |  |
| A1030 | Survey and mark out site | 2015-10-13 → 2018-09-29 (+1082d) | 2015-10-15 → 2018-10-03 (+1084d) |  | 61d → none |  | resources Land Surveyor [192 h] → Land Surveyor [24 h] |
| A1040 | Site Demarcation | 2015-10-15 → 2018-09-29 (+1080d) | 2015-10-16 → 2018-09-29 (+1079d) |  | 61d → none |  | resources Land Surveyor [64 h] → Land Surveyor [8 h] |
| A1050 | Excavation | 2015-10-17 → 2018-09-29 (+1078d) | 2015-10-22 → 2018-10-03 (+1077d) | 3.12d → 3d | 61d → none | A1040 FS+1d → A1040 | resources Truck Crane [32 ea] → Excavator [21 h] |
| A1060 | Grade Site | 2015-10-22 → 2018-09-29 (+1073d) | 2015-10-23 → 2018-10-02 (+1075d) |  | 61d → none |  | resources Operating Engineer [128 h] → Process Operations [16 h] |
| 2 | **Foundation** | 2015-10-13 → 2018-09-29 (+1082d) | 2015-10-28 → 2018-10-09 (+1077d) |  |  |  |  |
| A1070 | Laying of Foundation | 2015-10-13 → 2018-09-29 (+1082d) | 2015-10-16 → 2018-10-04 (+1084d) |  | 0d → none |  | resources Engineer Labor [256 h]; Steel Crew [256 h]; Carpentry Crew [256 h]; Mason [256 h] → Laborer Construction [32 h]; Ironworker [32 h]; Finish Carpenter [32 h]; Concrete [32 CY]; Mason [32 h] |
| A1080 | Slab Plumbing | 2015-10-16 → 2018-09-29 (+1079d) | 2015-10-24 → 2018-10-09 (+1081d) |  | 0d → none |  | resources Plumbing Crew [448 h] → Plumber [56 h] |
| A1090 | Pour and Float Slab Concrete | 2015-10-24 → 2018-09-29 (+1071d) | 2015-10-28 → 2018-10-02 (+1070d) |  | 0d → none |  | was named Pour and Float slab concrete; resources Concrete [16 cu yd] → Concrete [16 CY] |
| 3 | **Structure** | 2015-10-13 → 2018-09-29 (+1082d) | 2016-01-08 → 2018-11-06 (+1033d) |  |  |  |  |
| 1 | **Framing** | 2015-11-05 → 2018-09-29 (+1059d) | 2016-01-07 → 2018-11-06 (+1034d) |  |  |  |  |
| A1100 | Exterior Walls | 2015-11-05 → 2018-09-29 (+1059d) | 2015-12-01 → 2018-10-24 (+1058d) |  | 0d → none | A1090 FS+7d → A1090 | resources Mason [1280 h]; Plaster Crew [1280 h] → Mason [160 h]; Finishes & Fit-out Subcontractor [160 h] |
| A1110 | Interior Walls | 2015-12-04 → 2018-09-29 (+1030d) | 2016-01-05 → 2018-10-31 (+1030d) |  | 3d → none | A1100 FS+3d → A1100 | resources Plaster Crew [1600 h]; Mason [1600 h] → Mason [200 h]; Finishes & Fit-out Subcontractor [200 h] |
| A1120 | Exterior Cladding | 2015-12-01 → 2018-09-29 (+1033d) | 2016-01-07 → 2018-11-06 (+1034d) |  | 1d → none |  | resources Mason [1920 h] → Finishes & Fit-out Subcontractor [240 h]; Mason [240 h] |
| 2 | **Roof** | 2015-12-01 → 2018-09-29 (+1033d) | 2016-01-05 → 2018-10-18 (+1017d) |  |  |  |  |
| A1130 | Truss Placing | 2015-12-01 → 2018-09-29 (+1033d) | 2015-12-18 → 2018-10-18 (+1035d) |  | 0d → none |  | resources Steel Crew [960 h] → Ironworker [120 h] |
| A1140 | Roof Sheeting | 2015-12-18 → 2018-09-29 (+1016d) | 2015-12-31 → 2018-10-11 (+1015d) | 1d → 10d | 0d → none |  | resources Skilled Laborer [64 h] → Laborer Construction [80 h] |
| A1150 | Place Paper and Shingles | 2015-12-31 → 2018-09-29 (+1003d) | 2016-01-05 → 2018-10-03 (+1002d) |  | 0d → none |  | resources Skilled Laborer [192 h] → Laborer Construction [24 h] |
| 3 | **Interior** | 2015-10-13 → 2018-09-29 (+1082d) | 2016-01-08 → 2018-10-11 (+1007d) |  |  |  |  |
| A1160 | HVAC Ducting | 2016-01-05 → 2018-09-29 (+998d) | 2016-01-08 → 2018-10-03 (+999d) |  | 0d → none |  | resources Richard Collins [192 h] → Richard Collins [24 h] |
| A1170 | Install HVAC Unit | 2016-01-05 → 2018-09-29 (+998d) | 2016-01-07 → 2018-10-02 (+999d) |  | 1d → none | A1160 SS → A1160 | resources Richard Collins [128 h] → Richard Collins [16 h] |
| 2 | **Electrical** | 2015-12-01 → 2018-09-29 (+1033d) | 2015-12-16 → 2018-10-09 (+1028d) |  |  |  |  |
| A1180 | Breaker Box and Rough Wire | 2015-12-01 → 2018-09-29 (+1033d) | 2015-12-05 → 2018-10-05 (+1035d) |  | 19d → none |  | resources Electrical Crew [320 h] → Electrician [40 h] |
| A1190 | Finish Wiring | 2015-12-08 → 2018-09-29 (+1026d) | 2015-12-16 → 2018-10-09 (+1028d) |  | 19d → none |  | resources Electrical Crew [448 h] → Electrician [56 h] |
| 3 | **Plumbing** | 2015-12-01 → 2018-09-29 (+1033d) | 2015-12-12 → 2018-10-11 (+1034d) |  |  |  |  |
| A1200 | Install Rough plumbing lines | 2015-12-01 → 2018-09-29 (+1033d) | 2015-12-12 → 2018-10-11 (+1034d) |  | 7d → none |  | was named Install Rough Plumbing lines; resources Plumbing Crew [640 h] → Plumber [80 h] |
| 4 | **Decor** | 2015-10-13 → 2018-09-29 (+1082d) | 2015-12-30 → 2018-10-11 (+1016d) |  |  |  |  |
| A1210 | Placing Doors | 2015-12-12 → 2018-09-29 (+1022d) | 2015-12-23 → 2018-10-10 (+1022d) |  | 7d → none |  | resources Carpentry Crew [512 h] → Finish Carpenter [64 h] |
| A1220 | Door Placings and Baseboards | 2015-12-23 → 2018-09-29 (+1011d) | 2015-12-30 → 2018-10-06 (+1011d) |  | 7d → none |  | was named Door Casings and Baseboards; resources Carpentry Crew [384 h] → Finish Carpenter [48 h] |
| A1230 | Kitchen Cabinets | 2015-10-13 → 2018-09-29 (+1082d) | 2015-10-23 → 2018-10-11 (+1084d) |  | 61d → none |  | resources Carpentry Crew [640 h] → Finish Carpenter [80 h] |
| 5 | **Exterior** | 2015-10-13 → 2018-09-29 (+1082d) | 2015-11-03 → 2018-10-13 (+1075d) |  |  |  |  |
| A1240 | Place Window | 2015-10-13 → 2018-09-29 (+1082d) | 2015-10-27 → 2018-10-13 (+1082d) |  | 49d → none | none → A1120 | resources Glass Crew [768 h]; Carpentry Crew [768 h] → Glass & Glazing Subcontractor [96 h]; Finish Carpenter [96 h] |
| A1250 | Window Sidings | 2015-10-27 → 2018-09-29 (+1068d) | 2015-11-03 → 2018-10-05 (+1067d) |  | 49d → none |  | resources Siding Contractor [320 h] → Finish Carpenter [40 h] |
| 4 | **Landscaping** | 2015-11-03 → 2018-09-29 (+1061d) | 2015-11-07 → 2018-10-05 (+1063d) |  |  |  |  |
| A1260 | Tree Plantings | 2015-11-03 → 2018-09-29 (+1061d) | 2015-11-07 → 2018-10-05 (+1063d) |  | 49d → none |  | resources Landscape Crew [320 h] → Landscaping Subcontractor [40 h] |

## Version 4 (data date 2018-10-09, saved 2018-10-09, file c04_CONS_Home_tut02.xer)

Last finish 2018-11-06 → 2019-01-22 (+77d).

Changed:

| ID | Task | Start | Finish | Duration | Total float | Other |
| --- | --- | --- | --- | --- | --- | --- |
| A1000 | Project Start | 2018-09-29 → 2018-10-09 (+10d) | 2018-09-29 → 2018-10-09 (+10d) |  | none → 76d |  |
| A1010 | Project Management | 2018-09-29 → 2018-10-09 (+10d) | 2018-10-05 → 2019-01-22 (+109d) | 5d → 85d | none → 0d | resources Daniel Muller [680 h] → none |
| A1020 | Project Complete | 2018-09-29 → 2019-01-22 (+115d) | 2018-09-29 → 2019-01-22 (+115d) |  | none → 0d |  |
| 1 | **Grading** | 2018-09-29 → 2018-10-09 (+10d) | 2018-10-03 → 2018-10-18 (+15d) |  |  |  |
| A1030 | Survey and mark out site | 2018-09-29 → 2018-10-09 (+10d) | 2018-10-03 → 2018-10-11 (+8d) |  | none → 76d | resources Land Surveyor [24 h] → none |
| A1040 | Site Demarcation | 2018-09-29 → 2018-10-11 (+12d) | 2018-09-29 → 2018-10-12 (+13d) |  | none → 76d | resources Land Surveyor [8 h] → none |
| A1050 | Excavation | 2018-09-29 → 2018-10-12 (+13d) | 2018-10-03 → 2018-10-17 (+14d) |  | none → 76d | resources Excavator [21 h] → none |
| A1060 | Grade Site | 2018-09-29 → 2018-10-17 (+18d) | 2018-10-02 → 2018-10-18 (+16d) |  | none → 76d | resources Process Operations [16 h] → none |
| 2 | **Foundation** | 2018-09-29 → 2018-10-09 (+10d) | 2018-10-09 → 2018-10-24 (+15d) |  |  |  |
| A1070 | Laying of Foundation | 2018-09-29 → 2018-10-09 (+10d) | 2018-10-04 → 2018-10-12 (+8d) |  | none → 0d | resources Laborer Construction [32 h]; Ironworker [32 h]; Finish Carpenter [32 h]; Concrete [32 CY]; Mason [32 h] → none |
| A1080 | Slab Plumbing | 2018-09-29 → 2018-10-12 (+13d) | 2018-10-09 → 2018-10-20 (+11d) |  | none → 0d | resources Plumber [56 h] → none |
| A1090 | Pour and Float Slab Concrete | 2018-09-29 → 2018-10-20 (+21d) | 2018-10-02 → 2018-10-24 (+22d) |  | none → 0d | resources Concrete [16 CY] → none |
| 3 | **Structure** | 2018-09-29 → 2018-10-09 (+10d) | 2018-11-06 → 2019-01-22 (+77d) |  |  |  |
| 1 | **Framing** | 2018-09-29 → 2018-10-24 (+25d) | 2018-11-06 → 2018-12-25 (+49d) |  |  |  |
| A1100 | Exterior Walls | 2018-09-29 → 2018-10-24 (+25d) | 2018-10-24 → 2018-11-17 (+24d) |  | none → 0d | resources Mason [160 h]; Finishes & Fit-out Subcontractor [160 h] → none |
| A1110 | Interior Walls | 2018-09-29 → 2018-11-17 (+49d) | 2018-10-31 → 2018-12-19 (+49d) |  | none → 27d | resources Mason [200 h]; Finishes & Fit-out Subcontractor [200 h] → none |
| A1120 | Exterior Cladding | 2018-09-29 → 2018-11-17 (+49d) | 2018-11-06 → 2018-12-25 (+49d) |  | none → 0d | resources Finishes & Fit-out Subcontractor [240 h]; Mason [240 h] → none |
| 2 | **Roof** | 2018-09-29 → 2018-11-17 (+49d) | 2018-10-18 → 2018-12-22 (+65d) |  |  |  |
| A1130 | Truss Placing | 2018-09-29 → 2018-11-17 (+49d) | 2018-10-18 → 2018-12-06 (+49d) |  | none → 19d | resources Ironworker [120 h] → none |
| A1140 | Roof Sheeting | 2018-09-29 → 2018-12-06 (+68d) | 2018-10-11 → 2018-12-19 (+69d) |  | none → 19d | resources Laborer Construction [80 h] → none |
| A1150 | Place Paper and Shingles | 2018-09-29 → 2018-12-19 (+81d) | 2018-10-03 → 2018-12-22 (+80d) |  | none → 19d | resources Laborer Construction [24 h] → none |
| 3 | **Interior** | 2018-09-29 → 2018-10-09 (+10d) | 2018-10-11 → 2018-12-28 (+78d) |  |  |  |
| 1 | **Mechnical** | 2018-09-29 → 2018-12-22 (+84d) | 2018-10-03 → 2018-12-28 (+86d) |  |  |  |
| A1160 | HVAC Ducting | 2018-09-29 → 2018-12-22 (+84d) | 2018-10-03 → 2018-12-26 (+84d) |  | none → 19d | resources Richard Collins [24 h] → none |
| A1170 | Install HVAC Unit | 2018-09-29 → 2018-12-26 (+88d) | 2018-10-02 → 2018-12-28 (+87d) |  | none → 19d | resources Richard Collins [16 h] → none |
| 2 | **Electrical** | 2018-09-29 → 2018-11-17 (+49d) | 2018-10-09 → 2018-12-01 (+53d) |  |  |  |
| A1180 | Breaker Box and Rough Wire | 2018-09-29 → 2018-11-17 (+49d) | 2018-10-05 → 2018-11-23 (+49d) |  | none → 40d | resources Electrician [40 h] → none |
| A1190 | Finish Wiring | 2018-09-29 → 2018-11-23 (+55d) | 2018-10-09 → 2018-12-01 (+53d) |  | none → 40d | resources Electrician [56 h] → none |
| 3 | **Plumbing** | 2018-09-29 → 2018-11-17 (+49d) | 2018-10-11 → 2018-11-30 (+50d) |  |  |  |
| A1200 | Install Rough plumbing lines | 2018-09-29 → 2018-11-17 (+49d) | 2018-10-11 → 2018-11-30 (+50d) |  | none → 28d | resources Plumber [80 h] → none |
| 4 | **Decor** | 2018-09-29 → 2018-10-09 (+10d) | 2018-10-11 → 2018-12-18 (+68d) |  |  |  |
| A1230 | Kitchen Cabinets | 2018-09-29 → 2018-10-09 (+10d) | 2018-10-11 → 2018-10-19 (+8d) |  | none → 75d | resources Finish Carpenter [80 h] → none |
| A1210 | Placing Doors | 2018-09-29 → 2018-11-30 (+62d) | 2018-10-10 → 2018-12-11 (+62d) |  | none → 28d | resources Finish Carpenter [64 h] → none |
| A1220 | Door Placings and Baseboards | 2018-09-29 → 2018-12-11 (+73d) | 2018-10-06 → 2018-12-18 (+73d) |  | none → 28d | resources Finish Carpenter [48 h] → none |
| 5 | **Exterior** | 2018-09-29 → 2018-12-26 (+88d) | 2018-10-13 → 2019-01-16 (+95d) |  |  |  |
| A1240 | Place Window | 2018-09-29 → 2018-12-26 (+88d) | 2018-10-13 → 2019-01-09 (+88d) |  | none → 0d | resources Glass & Glazing Subcontractor [96 h]; Finish Carpenter [96 h] → none |
| A1250 | Window Sidings | 2018-09-29 → 2019-01-09 (+102d) | 2018-10-05 → 2019-01-16 (+103d) |  | none → 0d | resources Finish Carpenter [40 h] → none |
| 4 | **Landscaping** | 2018-09-29 → 2019-01-16 (+109d) | 2018-10-05 → 2019-01-22 (+109d) |  |  |  |
| A1260 | Tree Plantings | 2018-09-29 → 2019-01-16 (+109d) | 2018-10-05 → 2019-01-22 (+109d) |  | none → 0d | resources Landscaping Subcontractor [40 h] → none |

## Version 5 (data date 2018-10-24, saved 2018-12-06, file c08_CONS_HOME_tut01.xer)

Last finish 2019-01-22 → 2019-01-31 (+9d). Complete tasks 0 → 6.

Changed:

| ID | Task | Start | Finish | Complete | Total float | Predecessors | Other |
| --- | --- | --- | --- | --- | --- | --- | --- |
| A1000 | Project Start | 2018-10-09 A | 2018-10-09 A | 0% → 100% | 76d → none |  |  |
| A1010 | Project Management | 2018-10-09 A | 2019-01-22 → 2019-01-31 (+9d) | 0% → 5% |  |  | resources none → Daniel Muller [680 h] |
| A1020 | Project Complete | 2019-01-22 → 2019-01-31 (+9d) | 2019-01-22 → 2019-01-31 (+9d) |  |  | A1010 FF, A1170, A1190, A1230, A1260 → A1010 FF, A1170, A1190, A1230, A1260, A1170 FF, A1190 FF, A1230 FF, A1260 FF |  |
| 1 | **Grading** |  | 2018-10-18 → 2018-10-24 (+6d) |  |  |  |  |
| A1030 | Survey and mark out site | 2018-10-09 A | 2018-10-11 A | 0% → 100% | 76d → none |  | resources none → Land Surveyor [24 h] |
| A1040 | Site Demarcation | 2018-10-11 A | 2018-10-12 A | 0% → 100% | 76d → none |  | resources none → Land Surveyor [8 h] |
| A1050 | Excavation | 2018-10-12 A | 2018-10-17 A | 0% → 100% | 76d → none |  | resources none → Excavator [21 h] |
| A1060 | Grade Site | 2018-10-17 A | 2018-10-18 → 2018-10-24 A (+6d) | 0% → 100% | 76d → none |  | resources none → Process Operations [16 h] |
| 2 | **Foundation** | 2018-10-09 → 2018-10-23 (+14d) | 2018-10-24 → 2018-11-02 (+9d) |  |  |  |  |
| A1070 | Laying of Foundation | 2018-10-09 → 2018-10-23 A (+14d) | 2018-10-12 → 2018-10-26 A (+14d) | 0% → 100% | 0d → none |  | resources none → Laborer Construction [32 h]; Ironworker [32 h]; Finish Carpenter [32 h]; Concrete [32 CY]; Mason [32 h]; Laborer-Construction [32 h] |
| A1080 | Slab Plumbing | 2018-10-12 → 2018-10-26 A (+14d) | 2018-10-20 → 2018-11-01 (+12d) |  |  |  | resources none → Plumber [56 h] |
| A1090 | Pour and Float Slab Concrete | 2018-10-20 → 2018-11-01 (+12d) | 2018-10-24 → 2018-11-02 (+9d) |  |  |  | resources none → Concrete [16 CY] |
| 3 | **Structure** | 2018-10-09 → 2018-10-24 (+15d) | 2019-01-22 → 2019-01-31 (+9d) |  |  |  |  |
| 1 | **Framing** | 2018-10-24 → 2018-11-03 (+10d) | 2018-12-25 → 2019-01-04 (+10d) |  |  |  |  |
| A1100 | Exterior Walls | 2018-10-24 → 2018-11-03 (+10d) | 2018-11-17 → 2018-11-28 (+11d) |  |  |  | resources none → Mason [160 h]; Finishes & Fit-out Subcontractor [160 h] |
| A1110 | Interior Walls | 2018-11-17 → 2018-11-28 (+11d) | 2018-12-19 → 2018-12-28 (+9d) |  |  |  | resources none → Mason [200 h]; Finishes & Fit-out Subcontractor [200 h] |
| A1120 | Exterior Cladding | 2018-11-17 → 2018-11-28 (+11d) | 2018-12-25 → 2019-01-04 (+10d) |  |  |  | resources none → Finishes & Fit-out Subcontractor [240 h]; Mason [240 h] |
| 2 | **Roof** | 2018-11-17 → 2018-11-28 (+11d) | 2018-12-22 → 2019-01-02 (+11d) |  |  |  |  |
| A1130 | Truss Placing | 2018-11-17 → 2018-11-28 (+11d) | 2018-12-06 → 2018-12-18 (+12d) |  |  |  | resources none → Ironworker [120 h] |
| A1140 | Roof Sheeting | 2018-12-06 → 2018-12-18 (+12d) | 2018-12-19 → 2018-12-28 (+9d) |  |  |  | resources none → Laborer Construction [80 h]; Laborer-Construction [80 h] |
| A1150 | Place Paper and Shingles | 2018-12-19 → 2018-12-29 (+10d) | 2018-12-22 → 2019-01-02 (+11d) |  |  |  | resources none → Laborer Construction [24 h]; Laborer-Construction [24 h] |
| 3 | **Interior** | 2018-10-09 → 2018-10-24 (+15d) | 2018-12-28 → 2019-01-09 (+12d) |  |  |  |  |
| 1 | **Mechnical** | 2018-12-22 → 2019-01-02 (+11d) | 2018-12-28 → 2019-01-09 (+12d) |  |  |  |  |
| A1160 | HVAC Ducting | 2018-12-22 → 2019-01-02 (+11d) | 2018-12-26 → 2019-01-05 (+10d) |  |  |  | resources none → Richard Collins [24 h] |
| A1170 | Install HVAC Unit | 2018-12-26 → 2019-01-05 (+10d) | 2018-12-28 → 2019-01-09 (+12d) |  |  | A1160 → A1160, A1160 SS | resources none → Richard Collins [16 h] |
| 2 | **Electrical** | 2018-11-17 → 2018-11-28 (+11d) | 2018-12-01 → 2018-12-13 (+12d) |  |  |  |  |
| A1180 | Breaker Box and Rough Wire | 2018-11-17 → 2018-11-28 (+11d) | 2018-11-23 → 2018-12-05 (+12d) |  |  |  | resources none → Electrician [40 h] |
| A1190 | Finish Wiring | 2018-11-23 → 2018-12-05 (+12d) | 2018-12-01 → 2018-12-13 (+12d) |  |  |  | resources none → Electrician [56 h] |
| 3 | **Plumbing** | 2018-11-17 → 2018-11-28 (+11d) | 2018-11-30 → 2018-12-11 (+11d) |  |  |  |  |
| A1200 | Install Rough plumbing lines | 2018-11-17 → 2018-11-28 (+11d) | 2018-11-30 → 2018-12-11 (+11d) |  |  |  | resources none → Plumber [80 h] |
| 4 | **Decor** | 2018-10-09 → 2018-10-24 (+15d) | 2018-12-18 → 2018-12-28 (+10d) |  |  |  |  |
| A1230 | Kitchen Cabinets | 2018-10-09 → 2018-10-24 (+15d) | 2018-10-19 → 2018-11-03 (+15d) |  | 75d → 71d |  | resources none → Finish Carpenter [80 h] |
| A1210 | Placing Doors | 2018-11-30 → 2018-12-11 (+11d) | 2018-12-11 → 2018-12-20 (+9d) |  |  |  | resources none → Finish Carpenter [64 h] |
| A1220 | Door Casings and Baseboards | 2018-12-11 → 2018-12-20 (+9d) | 2018-12-18 → 2018-12-28 (+10d) |  |  |  | was named Door Placings and Baseboards; resources none → Finish Carpenter [48 h] |
| 5 | **Exterior** | 2018-12-26 → 2019-01-04 (+9d) | 2019-01-16 → 2019-01-25 (+9d) |  |  |  |  |
| A1240 | Place Windows | 2018-12-26 → 2019-01-04 (+9d) | 2019-01-09 → 2019-01-19 (+10d) |  |  |  | was named Place Window; resources none → Glass & Glazing Subcontractor [96 h]; Finish Carpenter [96 h] |
| A1250 | Window Sidings | 2019-01-09 → 2019-01-19 (+10d) | 2019-01-16 → 2019-01-25 (+9d) |  |  |  | resources none → Finish Carpenter [40 h] |
| 4 | **Landscaping** | 2019-01-16 → 2019-01-25 (+9d) | 2019-01-22 → 2019-01-31 (+9d) |  |  |  |  |
| A1260 | Tree Plantings | 2019-01-16 → 2019-01-25 (+9d) | 2019-01-22 → 2019-01-31 (+9d) |  |  |  | resources none → Landscaping Subcontractor [40 h] |
